# Mechanical Tasks Oct 17 06

How a schedule from MS Project changed from version to version. A marks actual dates.

## Version 1 (saved 2006-10-20, file Mechanical Tasks Oct 17 06.mpp)

| ID | WBS | Task | Duration | Start | Finish | Predecessors | Complete | Constraint |
| --- | --- | --- | --- | --- | --- | --- | --- | --- |
| 1 | 1 | **Atlantis Cruise Tasks** | 103d? | 2006-04-18 08:00 A | 2006-09-07 17:00 A |  | 100% |  |
| 2 | 1.1 | **Weight drop** | 27.5d? | 2006-04-24 08:00 A | 2006-05-31 12:00 A |  | 100% |  |
| 3 |  | Modify weight drop assembly | 8d | 2006-04-24 08:00 A | 2006-05-04 12:00 A |  | 100% |  |
| 4 |  | order iron rod and hoops | 1d? | 2006-05-04 13:00 A | 2006-05-05 12:00 A | 3 | 100% |  |
| 5 |  | ship material | 10d | 2006-05-05 13:00 A | 2006-05-19 12:00 A | 4 | 100% |  |
| 6 |  | Cut rod and hoops | 2d? | 2006-05-19 13:00 A | 2006-05-23 12:00 A | 5 | 100% |  |
| 7 |  | weld hoops to weights | 2d? | 2006-05-23 13:00 A | 2006-05-25 12:00 A | 6 | 100% |  |
| 8 |  | Install weight | 4d? | 2006-05-25 13:00 A | 2006-05-31 12:00 A | 7 | 100% |  |
| 9 | 1.2 | **Track tensioner** | 22d? | 2006-04-24 08:00 A | 2006-05-23 17:00 A |  | 100% |  |
| 10 |  | Fabricate Ti springs | 2d? | 2006-04-24 08:00 A | 2006-04-25 17:00 A |  | 100% |  |
| 11 |  | Receive springs from SIO | 0d | 2006-05-22 08:00 A | 2006-05-22 08:00 A |  | 100% | start no earlier than 2006-05-22 08:00 |
| 12 |  | Install springs and test | 2d? | 2006-05-22 08:00 A | 2006-05-23 17:00 A | 11 | 100% |  |
| 13 | 1.3 | **Argos transmitter** | 52d? | 2006-04-24 08:00 A | 2006-07-04 17:00 A |  | 100% |  |
| 14 |  | set up account | 1d? | 2006-04-24 08:00 A | 2006-04-25 12:00 A |  | 100% |  |
| 15 |  | Design and build a bracket | 2d? | 2006-07-03 08:00 A | 2006-07-04 17:00 A | 70 | 100% |  |
| 16 | 1.4 | **Spar Buoy** | 29d? | 2006-04-24 08:00 A | 2006-06-01 17:00 A |  | 100% |  |
| 17 |  | Update model with SIO Spar Buoy components | 1d? | 2006-04-24 08:00 A | 2006-04-25 12:00 A |  | 100% |  |
| 18 |  | ship components from SIO to MBARI | 10d? | 2006-05-15 08:00 A | 2006-05-26 17:00 A |  | 100% | start no earlier than 2006-05-15 08:00 |
| 19 |  | Assemble spar buoy assembly | 4d? | 2006-05-29 08:00 A | 2006-06-01 17:00 A | 18 | 100% |  |
| 20 |  | confirm Atlantis can receive 159.480 MHz | 0.25d? | 2006-04-24 08:00 A | 2006-04-24 10:00 A |  | 100% |  |
| 21 |  | order connector rope | 0.5d? | 2006-04-24 08:00 A | 2006-04-24 12:00 A |  | 100% |  |
| 22 | 1.5 | **Oil compensator** | 20d? | 2006-05-01 08:00 A | 2006-05-26 17:00 A |  | 100% |  |
| 23 |  | Fabricate parts | 14d | 2006-05-01 08:00 A | 2006-05-18 17:00 A |  | 100% | start no earlier than 2006-05-01 08:00 |
| 24 |  | Build up, fill and test | 2d? | 2006-05-19 08:00 A | 2006-05-22 17:00 A | 23, 3 | 100% |  |
| 25 |  | Assemble plumbing | 2d? | 2006-05-23 08:00 A | 2006-05-24 17:00 A | 24 | 100% |  |
| 26 |  | Mount on Rover | 2d? | 2006-05-25 08:00 A | 2006-05-26 17:00 A | 25 | 100% |  |
| 27 | 1.6 | **Shipboard cradle** | 10d? | 2006-05-29 08:00 A | 2006-06-09 17:00 A |  | 100% |  |
| 28 |  | Design cradle | 0.5d? | 2006-05-29 08:00 A | 2006-05-29 12:00 A | 26 | 100% |  |
| 29 |  | order parts | 1.5d? | 2006-05-29 13:00 A | 2006-05-30 17:00 A | 28 | 100% |  |
| 30 |  | fabricate and install | 8d? | 2006-05-31 08:00 A | 2006-06-09 17:00 A | 29 | 100% |  |
| 31 |  | CDR prep | 2d? | 2006-04-24 08:00 A | 2006-04-26 12:00 A |  | 100% |  |
| 32 | 1.8 | **Pressure Housings** | 46.5d? | 2006-04-18 08:00 A | 2006-06-21 12:00 A |  | 100% |  |
| 33 | 1.8.1 | **Battery Sphere** | 43d? | 2006-04-18 08:00 A | 2006-06-15 17:00 A |  | 100% |  |
| 34 |  | Design alkaline battery pack frame | 2d? | 2006-05-09 13:00 A | 2006-05-11 12:00 A | 51 | 100% |  |
| 35 |  | Fabricate internal frame and mounts | 4d? | 2006-06-12 08:00 A | 2006-06-15 17:00 A | 34, 30 | 100% |  |
| 36 |  | Machine Housing | 20d | 2006-04-18 08:00 A | 2006-05-15 17:00 A |  | 100% | start no earlier than 2006-04-18 08:00 |
| 37 |  | QC machine work and assemble | 4d? | 2006-05-16 08:00 A | 2006-05-19 17:00 A | 36 | 100% | start no earlier than 2006-04-18 08:00 |
| 38 |  | Helium Leak test | 2d? | 2006-05-22 08:00 A | 2006-05-23 17:00 A | 37 | 100% |  |
| 39 |  | Mount on Rover | 2d? | 2006-05-24 08:00 A | 2006-05-25 17:00 A | 38 | 100% |  |
| 40 | 1.8.2 | **MVC Sphere** | 34d? | 2006-04-18 08:00 A | 2006-06-02 17:00 A |  | 100% |  |
| 41 |  | Design internal chassis for MVC | 2d? | 2006-04-24 08:00 A | 2006-04-26 12:00 A |  | 100% |  |
| 42 |  | Design Seacon plugs | 1d? | 2006-04-24 08:00 A | 2006-04-25 12:00 A |  | 100% |  |
| 43 |  | Machine plugs | 1d? | 2006-04-25 13:00 A | 2006-04-26 12:00 A | 42 | 100% |  |
| 44 |  | Machine Housing | 20d | 2006-04-18 08:00 A | 2006-05-15 17:00 A |  | 100% | start no earlier than 2006-04-18 08:00 |
| 45 |  | QC machine work and assemble | 4d? | 2006-05-22 08:00 A | 2006-05-25 17:00 A | 44, 37 | 100% |  |
| 46 |  | Helium leak test | 2d? | 2006-05-26 08:00 A | 2006-05-29 17:00 A | 45 | 100% |  |
| 47 |  | Mount on Rover | 4d? | 2006-05-30 08:00 A | 2006-06-02 17:00 A | 46 | 100% |  |
| 48 | 1.8.3 | **Motor controller** | 42.5d? | 2006-04-24 08:00 A | 2006-06-21 12:00 A |  | 100% |  |
| 49 |  | Design motor controller housings | 6d? | 2006-04-24 08:00 A | 2006-05-04 12:00 A |  | 100% |  |
| 50 |  | Confirm design with FEA | 1d? | 2006-05-04 13:00 A | 2006-05-05 12:00 A | 49 | 100% |  |
| 51 |  | Generate machine prints for Ti parts | 2d? | 2006-05-05 13:00 A | 2006-05-09 12:00 A | 50 | 100% |  |
| 52 |  | Drawing check | 1d? | 2006-05-09 13:00 A | 2006-05-10 12:00 A | 51 | 100% |  |
| 53 |  | Machine parts | 15d? | 2006-05-10 13:00 A | 2006-05-31 12:00 A | 52 | 100% |  |
| 54 |  | QC parts and assemble | 1d? | 2006-05-31 13:00 A | 2006-06-01 12:00 A | 53 | 100% |  |
| 55 |  | Pressure check | 1d? | 2006-06-01 13:00 A | 2006-06-02 12:00 A | 54 | 100% |  |
| 56 |  | Electronics Assembly | 1d? | 2006-06-02 13:00 A | 2006-06-05 12:00 A | 55 | 100% |  |
| 57 |  | Final assembly, He leak test | 4d? | 2006-06-05 13:00 A | 2006-06-09 12:00 A | 56 | 100% |  |
| 58 |  | Mount on Rover | 4d? | 2006-06-09 13:00 A | 2006-06-15 12:00 A | 57 | 100% |  |
| 59 |  | Design Ti sphere mounting brackets | 4d? | 2006-04-24 08:00 A | 2006-04-28 12:00 A |  | 100% |  |
| 60 | 1.8.3.12 | **Motion monitoring data logger** | 7d? | 2006-05-09 13:00 A | 2006-05-18 12:00 A |  | 100% |  |
| 61 |  | Confirm specs with Andy | 2d? | 2006-05-09 13:00 A | 2006-05-11 12:00 A | 51 | 100% |  |
| 62 |  | Program and build up system | 1d? | 2006-05-11 13:00 A | 2006-05-12 12:00 A | 61 | 100% |  |
| 63 |  | Mount to Rover | 4d? | 2006-05-12 13:00 A | 2006-05-18 12:00 A | 62 | 100% |  |
| 64 | 1.8.3.13 | **Homer transponder** | 42.5d? | 2006-04-24 08:00 A | 2006-06-21 12:00 A |  | 100% |  |
| 65 |  | Check out deep homer from DMO | 1d? | 2006-04-24 08:00 A | 2006-04-25 12:00 A |  | 100% |  |
| 66 |  | Fabricate bracket and mount Homer | 4d? | 2006-06-15 13:00 A | 2006-06-21 12:00 A | 58 | 100% |  |
| 67 |  | Design lifting sling/eye | 4d? | 2006-06-21 13:00 A | 2006-06-27 12:00 A | 66 | 100% |  |
| 68 |  | Remount floatation blocks | 2d? | 2006-06-27 13:00 A | 2006-06-29 12:00 A | 67 | 100% |  |
| 69 |  | Design brackets for A-modem | 0.5d? | 2006-06-29 13:00 A | 2006-06-29 17:00 A | 68 | 100% |  |
| 70 |  | Design brackets for current meter | 1d? | 2006-06-30 08:00 A | 2006-06-30 17:00 A | 69 | 100% |  |

| ID | WBS | Task | Duration | Start | Finish | Predecessors | Complete | Total float | Constraint |
| --- | --- | --- | --- | --- | --- | --- | --- | --- | --- |
| 71 |  | Mount Football Floats | 4d? | 2006-07-03 08:00 A | 2006-07-06 17:00 A | 70 | 100% |  |  |
| 72 |  | Measure wet weight | 1d? | 2006-07-07 08:00 A | 2006-07-07 17:00 A | 71 | 100% |  |  |
| 73 |  | Update trim and balance | 1d? | 2006-07-10 08:00 A | 2006-07-10 17:00 A | 72 | 100% |  |  |
| 74 |  | Design and order lead ballast | 1d? | 2006-07-11 08:00 A | 2006-07-11 17:00 A | 73 | 100% |  |  |
| 75 | 1.17 | **Testing** | 34d? | 2006-06-05 08:00 A | 2006-07-21 08:00 A |  | 100% |  |  |
| 76 |  | Lab Tests | 2d? | 2006-06-05 08:00 A | 2006-06-06 17:00 A |  | 100% |  | start no earlier than 2006-06-05 08:00 |
| 77 |  | Tank Testing | 1d? | 2006-07-12 08:00 A | 2006-07-12 17:00 A | 74 | 100% |  | start no earlier than 2006-06-07 08:00 |
| 78 |  | Ready for Sea Tests | 0d | 2006-07-12 17:00 A | 2006-07-12 17:00 A | 77 | 100% |  |  |
| 79 |  | Pt. Lobos | 4d? | 2006-07-13 08:00 A | 2006-07-18 17:00 A | 78 | 100% |  | finish no earlier than 2006-06-19 17:00 |
| 80 |  | Upgrades/Rework | 1d? | 2006-07-19 08:00 A | 2006-07-19 17:00 A | 79 | 100% |  |  |
| 81 |  | Final pool test | 1d? | 2006-07-20 08:00 A | 2006-07-20 17:00 A | 80 | 100% |  |  |
| 82 |  | Ready for shipment | 0d | 2006-07-21 08:00 A | 2006-07-21 08:00 A |  | 100% |  | start no earlier than 2006-07-21 08:00 |
| 83 |  | Atlantis Cruise | 23d | 2006-08-08 08:00 A | 2006-09-07 17:00 A |  | 100% |  | start no earlier than 2006-08-08 08:00 |
| 84 | 2 | **Flyer Cruise Tasks** | 160.5d? | 2006-04-24 08:00 A | 2006-12-04 12:00 |  | 14% | 0d |  |
| 85 | 2.1 | **Design** | 21d? | 2006-10-02 08:00 A | 2006-10-30 17:00 |  | 71% | 24.5d |  |
| 86 |  | Design Racks | 8d? | 2006-10-02 08:00 A | 2006-10-18 17:00 A |  | 100% |  | finish no earlier than 2006-10-18 17:00 |
| 87 |  | Design Respirometers | 8d? | 2006-10-03 08:00 A | 2006-10-27 17:00 | 86 | 40% | 25.1d | finish no earlier than 2006-10-18 17:00 |
| 88 |  | Clean up Rover Drawings | 2d? | 2006-10-04 08:00 A | 2006-10-30 17:00 | 87 | 80% | 24.5d | finish no earlier than 2006-10-18 17:00 |
| 89 |  | CDR | 5d | 2006-10-12 08:00 A | 2006-10-18 17:00 |  | 3% | 1.65d |  |
| 90 | 2.3 | **Complete Drawing package for shop** | 3.7d? | 2006-10-19 08:00 A | 2006-10-24 14:36 |  | 5% | 28.8d |  |
| 91 | 2.3.1 | **Rack drawings** | 2d? | 2006-10-19 08:00 | 2006-10-20 17:00 |  |  | 8.3d |  |
| 92 |  | Frame | 0.5d? | 2006-10-19 08:00 | 2006-10-19 12:00 | 89 |  | 29d |  |
| 93 |  | I-beam blocks | 0.5d? | 2006-10-19 13:00 | 2006-10-19 17:00 | 92 |  | 29d |  |
| 94 | 2.3.1.3 | **Motor assembly** | 1d? | 2006-10-19 08:00 | 2006-10-19 17:00 |  |  | 8.3d |  |
| 95 |  | finish output shaft | 0.5d? | 2006-10-19 08:00 | 2006-10-19 12:00 | 89 |  | 8.3d |  |
| 96 |  | other | 0.5d? | 2006-10-19 13:00 | 2006-10-19 17:00 | 95 |  | 8.3d |  |
| 97 | 2.3.1.4 | **Leadscrew assembly** | 1d? | 2006-10-20 08:00 | 2006-10-20 17:00 |  |  | 26.8d |  |
| 98 |  | Leadscrew mods | 0.5d? | 2006-10-20 08:00 | 2006-10-20 12:00 | 96 |  | 26.8d |  |
| 99 |  | bearing support details | 0.5d? | 2006-10-20 13:00 | 2006-10-20 17:00 | 98 |  | 26.8d |  |
| 100 |  | Cart | 0.5d? | 2006-10-20 08:00 | 2006-10-20 12:00 | 93 |  | 29d |  |
| 101 | 2.3.2 | **respirometer drawings** | 3.7d? | 2006-10-19 08:00 A | 2006-10-24 14:36 |  | 9% | 28.8d |  |
| 102 |  | chambers | 0.5d? | 2006-10-19 08:00 | 2006-10-19 12:00 | 89 |  | 29.8d |  |
| 103 |  | optode | 0.2d? | 2006-10-19 13:00 | 2006-10-19 14:36 | 102 |  | 29.8d |  |
| 104 |  | vents | 1d? | 2006-10-19 14:36 | 2006-10-20 14:36 | 103 |  | 29.8d |  |
| 105 |  | stirer | 1d? | 2006-10-20 14:36 | 2006-10-23 14:36 | 104 |  | 29.8d |  |
| 106 |  | j-box | 0.5d? | 2006-10-24 09:36 A | 2006-10-24 14:36 A | 105 | 100% |  |  |
| 107 |  | touchdown switch | 0.5d? | 2006-10-19 08:00 | 2006-10-19 12:00 | 89 |  | 30d |  |
| 108 |  | chamber knife | 1d? | 2006-10-19 13:00 | 2006-10-20 12:00 | 107 |  | 30d |  |
| 109 |  | Pump, plumbing and manifold | 1d? | 2006-10-20 13:00 | 2006-10-23 12:00 | 108 |  | 30d |  |
| 110 |  | Machine parts | 20d | 2006-10-20 08:00 | 2006-11-16 17:00 | 96 |  | 8.3d |  |
| 111 |  | Order materials | 1d? | 2006-10-20 13:00 | 2006-10-23 12:00 | 100 |  | 29d |  |
| 112 |  | Order U/W connectors | 20d | 2006-10-20 08:00 | 2006-11-16 17:00 |  |  | 2.65d | start no earlier than 2006-10-20 08:00 |
| 113 | 2.7 | **Rack Assembly** | 152.2d? | 2006-04-24 08:00 | 2006-11-22 09:36 | 118 |  | 8.3d |  |
| 114 | 2.7.1 | **Fab Frame** | 131.5d? | 2006-04-24 08:00 | 2006-10-24 12:00 |  |  | 29d |  |
| 115 |  | Fab rack mount blocks | 1d? | 2006-10-23 13:00 | 2006-10-24 12:00 | 111 |  | 29d |  |
| 116 |  | Cut I-beams | 0.4d? | 2006-04-24 08:00 | 2006-04-24 11:12 |  |  | 157.1d |  |
| 117 |  | mount blocks | 0.2d? | 2006-04-24 11:12 | 2006-04-25 08:48 | 116 |  | 156.6d |  |
| 118 |  | fab tube mounts | 0.5d? | 2006-04-25 08:48 | 2006-04-25 13:48 | 117 |  | 156.6d |  |
| 119 |  | square up and assemble frame | 0.4d? | 2006-04-25 13:48 | 2006-04-25 17:00 | 118 |  | 156.6d |  |
| 120 | 2.7.2 | **Cart** | 148d? | 2006-04-26 08:00 | 2006-11-17 17:00 |  |  | 10.5d |  |
| 121 |  | Cut and clean up shafts | 0.2d? | 2006-04-26 08:00 | 2006-04-26 09:36 | 119 |  | 156.6d |  |
| 122 |  | fab wheels | 0.5d? | 2006-04-26 09:36 | 2006-04-26 14:36 | 121 |  | 156.6d |  |
| 123 |  | fab and mount sliders | 0.2d? | 2006-04-26 14:36 | 2006-04-26 16:12 | 122 |  | 156.6d |  |
| 124 |  | assemble cart | 1d? | 2006-11-17 08:00 | 2006-11-17 17:00 | 123, 110 |  | 10.5d |  |
| 125 | 2.7.3 | **Motor Assembly** | 150.7d? | 2006-04-24 08:00 | 2006-11-20 14:36 |  |  | 9.8d |  |
| 126 |  | prep motors for oil | 0.5d? | 2006-10-23 08:00 | 2006-10-23 12:00 | 99 |  | 26.8d |  |
| 127 |  | wireup and build motor assembly | 0.5d? | 2006-11-17 08:00 | 2006-11-17 12:00 | 126, 110 |  | 8.3d |  |
| 128 |  | add inserts and standoffs to amp endcap | 0.2d? | 2006-11-17 13:00 | 2006-11-17 14:36 | 127 |  | 8.3d |  |
| 129 |  | install and wireup ez-servo | 0.5d? | 2006-11-17 14:36 | 2006-11-20 09:36 | 128 |  | 8.3d |  |
| 130 |  | assemble comp plumbing to motor block | 0.5d? | 2006-11-20 09:36 | 2006-11-20 14:36 | 129 |  | 8.3d |  |
| 131 |  | Modify leadscrew | 1d? | 2006-04-24 08:00 | 2006-04-25 12:00 |  |  | 159d |  |
| 132 |  | assemble leadscrew | 1d? | 2006-04-24 08:00 | 2006-04-25 12:00 |  |  | 159d |  |
| 133 |  | Rack assembly | 1d? | 2006-11-20 14:36 | 2006-11-21 14:36 | 130 |  | 8.3d |  |
| 134 |  | Final assembly | 0.5d? | 2006-11-21 14:36 | 2006-11-22 09:36 | 133 |  | 8.3d |  |
| 135 | 2.8 | **Respirometer Assembly** | 24.85d? | 2006-10-19 08:00 | 2006-11-22 15:48 |  |  | 7.65d |  |
| 136 | 2.8.1 | **Chambers** | 23.3d? | 2006-10-19 08:00 | 2006-11-21 10:24 |  |  | 9.2d |  |
| 137 |  | Cut tube | 0.2d? | 2006-11-20 14:36 | 2006-11-20 16:12 | 130 |  | 9.2d |  |
| 138 |  | Glue & screw top to tube | 0.2d? | 2006-11-20 16:12 | 2006-11-21 08:48 | 110, 137 |  | 9.2d |  |
| 139 |  | Glue & screw bars to top | 0.2d? | 2006-11-21 08:48 | 2006-11-21 10:24 | 138 |  | 9.2d |  |
| 140 | 2.8.1.4 | **Stirer** | 3d? | 2006-10-19 08:00 | 2006-10-23 17:00 |  |  | 20.55d |  |

| ID | WBS | Task | Duration | Start | Finish | Predecessors | Complete | Total float | Constraint |
| --- | --- | --- | --- | --- | --- | --- | --- | --- | --- |
| 141 |  | Fabricate paddles, rulon bushing, | 1d? | 2006-10-19 08:00 | 2006-10-19 17:00 | 89 |  | 20.55d |  |
| 142 |  | Assemble 1 | 1d? | 2006-10-20 08:00 | 2006-10-20 17:00 | 141 |  | 20.55d |  |
| 143 |  | Assemble 2 | 1d? | 2006-10-23 08:00 | 2006-10-23 17:00 | 142 |  | 20.55d |  |
| 144 | 2.8.1.5 | **Optode** | 1.2d? | 2006-10-19 08:00 | 2006-10-20 09:36 |  |  | 23.05d |  |
| 145 |  | Wire up optode to adaptor and U/W conn | 0.2d? | 2006-10-19 08:00 | 2006-10-19 09:36 | 89 |  | 23.05d |  |
| 146 |  | Calibrate - Smith Lab | 1d? | 2006-10-19 09:36 | 2006-10-20 09:36 | 145 |  | 23.05d |  |
| 147 | 2.8.1.6 | **Vents** | 2.4d? | 2006-10-24 16:12 | 2006-10-27 10:24 |  |  | 20.55d |  |
| 148 |  | assemble parts | 1d? | 2006-10-24 16:12 | 2006-10-25 16:12 | 166 |  | 20.55d |  |
| 149 |  | fill with oil and test | 0.2d? | 2006-10-25 16:12 | 2006-10-26 08:48 | 148 |  | 20.55d |  |
| 150 |  | cold room test | 0.2d? | 2006-10-26 08:48 | 2006-10-26 10:24 | 149 |  | 20.55d |  |
| 151 |  | Build 5 more units | 1d? | 2006-10-26 10:24 | 2006-10-27 10:24 | 150 |  | 20.55d |  |
| 152 | 2.8.1.7 | **Touchdown switch** | 0.4d? | 2006-10-27 10:24 | 2006-10-27 14:36 |  |  | 22.7d |  |
| 153 |  | Assemble and glue body | 0.2d? | 2006-10-27 10:24 | 2006-10-27 12:00 | 151 |  | 22.7d |  |
| 154 |  | Assemble and test plunger | 0.2d? | 2006-10-27 13:00 | 2006-10-27 14:36 | 153 |  | 22.7d |  |
| 155 | 2.8.1.8 | **Hall effect switches (3)** | 2d? | 2006-10-19 08:00 | 2006-10-20 17:00 |  |  | 30.5d |  |
| 156 |  | mold switches | 1d? | 2006-10-19 08:00 | 2006-10-19 17:00 | 89 |  | 30.5d |  |
| 157 |  | assemble wiring and plumbing | 1d? | 2006-10-20 08:00 | 2006-10-20 17:00 | 156 |  | 30.5d |  |
| 158 | 2.8.1.9 | **Sprayer** | 3.1d? | 2006-10-27 14:36 | 2006-11-01 15:24 |  |  | 22.7d |  |
| 159 |  | Modify pump | 0.3d? | 2006-10-27 14:36 | 2006-10-27 17:00 | 154 |  | 22.7d |  |
| 160 |  | Mount pump | 0.3d? | 2006-10-30 08:00 | 2006-10-30 10:24 | 159 |  | 22.7d |  |
| 161 |  | fab manifold, glue into chamber | 1d? | 2006-10-30 10:24 | 2006-10-31 10:24 | 160 |  | 22.7d |  |
| 162 |  | assemble plumbing | 1d? | 2006-10-31 10:24 | 2006-11-01 10:24 | 161 |  | 22.7d |  |
| 163 |  | test | 0.5d? | 2006-11-01 10:24 | 2006-11-01 15:24 | 162 |  | 22.7d |  |
| 164 |  | mount stirer | 0.2d? | 2006-10-24 08:00 | 2006-10-24 09:36 | 143 |  | 20.55d |  |
| 165 |  | mount valves | 0.5d? | 2006-10-24 09:36 | 2006-10-24 14:36 | 164 |  | 20.55d |  |
| 166 |  | mount optode | 0.2d? | 2006-10-24 14:36 | 2006-10-24 16:12 | 165, 146 |  | 20.55d |  |
| 167 |  | mount knife | 1d? | 2006-10-24 16:12 | 2006-10-25 16:12 | 166 |  | 27.6d |  |
| 168 |  | Bench test 1 rack | 0.5d? | 2006-11-17 08:00 | 2006-11-17 12:00 | 112 |  | 2.65d |  |
| 169 |  | Bench test chamber | 0.5d? | 2006-11-17 13:00 | 2006-11-17 17:00 | 168 |  | 2.65d |  |
| 170 |  | cold room tests | 0.1d? | 2006-11-20 08:00 | 2006-11-20 08:48 | 169 |  | 2.65d |  |
| 171 |  | flow tests | 0.25d? | 2006-11-20 08:48 | 2006-11-20 10:48 | 170 |  | 2.65d |  |
| 172 |  | Build 2nd rack/chamber assembly | 2d? | 2006-11-20 10:48 | 2006-11-22 10:48 | 171 |  | 2.65d |  |
| 173 |  | Mount on Rover | 0.5d? | 2006-11-22 10:48 | 2006-11-22 15:48 | 172 |  | 2.65d |  |
| 174 | 2.9 | **Other Tasks** | 38.5d? | 2006-10-11 08:00 A | 2006-12-04 12:00 |  | 38% | 0d |  |
| 175 |  | Re-assemble Strb drive motor and both amps | 1d? | 2006-11-16 09:36 A | 2006-11-17 09:36 | 151 | 85% | 5.8d |  |
| 176 |  | Modify drop weight jack | 1d? | 2006-10-11 08:00 A | 2006-10-11 17:00 |  | 75% | 36.3d |  |
| 177 |  | Re-load drop weight | 0.2d? | 2006-10-12 08:00 | 2006-10-12 09:36 | 176 |  | 36.3d |  |
| 178 |  | Buy, mount and wireup camera(s) | 1d? | 2006-10-12 09:36 | 2006-10-13 09:36 | 177 |  | 36.3d |  |
| 179 |  | Assemble and test acoustic modem | 0.5d? | 2006-12-04 08:00 | 2006-12-04 12:00 |  |  | 0d | as late as possible |
| 180 |  | Assembe two more oil compensators, mount, fill and bleed | 0.5d? | 2006-11-17 09:36 | 2006-11-17 14:36 | 175 |  | 5.8d |  |
| 181 |  | Tank tests | 3d | 2006-11-22 15:48 | 2006-11-27 15:48 | 173, 180 |  | 2.65d |  |
| 182 |  | Rework | 1d? | 2006-11-27 15:48 | 2006-11-28 15:48 | 181 |  | 2.65d |  |
| 183 |  | Retest in tank | 1d? | 2006-11-28 15:48 | 2006-11-29 15:48 | 182 |  | 2.65d |  |
| 184 |  | Pt. Lobos Cruise | 0.5d? | 2006-12-04 08:00 | 2006-12-04 12:00 |  |  | 0d | start no earlier than 2006-12-04 08:00 |

## Version 2 (saved 2006-11-13, file Rover Mechanical Tasks Fall 06 de-scope.mpp)

Last finish stays 2006-12-04. Complete tasks 71 → 74.

Added:

| ID | Task | Duration | Start | Finish | Resources |
| --- | --- | --- | --- | --- | --- |
| 136 | Assemble | 1d? | 2006-04-24 | 2006-04-25 | John |
| 139 | assemble parts for 1 vent | 2d? | 2006-04-24 | 2006-04-25 | Jim |

Removed: 135 Respirometer Assembly; 136 Chambers; 137 Cut tube; 138 Glue & screw top to tube; 139 Glue & screw bars to top; 140 Stirer; 141 Fabricate paddles, rulon bushing,; 142 Assemble 1; 143 Assemble 2; 144 Optode; 145 Wire up optode to adaptor and U/W conn; 146 Calibrate - Smith Lab; 148 assemble parts; 151 Build 5 more units; 153 Assemble and glue body; 158 Sprayer; 159 Modify pump; 160 Mount pump; 161 fab manifold, glue into chamber; 162 assemble plumbing; 163 test; 164 mount stirer; 165 mount valves; 166 mount optode; 167 mount knife; 168 Bench test 1 rack; 169 Bench test chamber; 170 cold room tests; 171 flow tests; 172 Build 2nd rack/chamber assembly; 173 Mount on Rover

Changed:

| ID | Task | Start | Finish | Other |
| --- | --- | --- | --- | --- |
| 1 | **Atlantis Cruise Tasks** | 2006-04-18 08:00 A → 2006-04-18 A | 2006-09-07 17:00 A → 2006-09-07 A |  |
| 2 | **Weight drop** | 2006-04-24 08:00 A → 2006-04-24 A | 2006-05-31 12:00 A → 2006-05-31 A |  |
| 3 | Modify weight drop assembly | 2006-04-24 08:00 A → 2006-04-24 A | 2006-05-04 12:00 A → 2006-05-04 A |  |
| 4 | order iron rod and hoops | 2006-05-04 13:00 A → 2006-05-04 A | 2006-05-05 12:00 A → 2006-05-05 A |  |
| 5 | ship material | 2006-05-05 13:00 A → 2006-05-05 A | 2006-05-19 12:00 A → 2006-05-19 A |  |
| 6 | Cut rod and hoops | 2006-05-19 13:00 A → 2006-05-19 A | 2006-05-23 12:00 A → 2006-05-23 A |  |
| 7 | weld hoops to weights | 2006-05-23 13:00 A → 2006-05-23 A | 2006-05-25 12:00 A → 2006-05-25 A |  |
| 8 | Install weight | 2006-05-25 13:00 A → 2006-05-25 A | 2006-05-31 12:00 A → 2006-05-31 A |  |
| 9 | **Track tensioner** | 2006-04-24 08:00 A → 2006-04-24 A | 2006-05-23 17:00 A → 2006-05-23 A |  |
| 10 | Fabricate Ti springs | 2006-04-24 08:00 A → 2006-04-24 A | 2006-04-25 17:00 A → 2006-04-25 A |  |
| 11 | Receive springs from SIO | 2006-05-22 08:00 A → 2006-05-22 A | 2006-05-22 08:00 A → 2006-05-22 A | constraint start no earlier than 2006-05-22 08:00 → start no earlier than 2006-05-22 |
| 12 | Install springs and test | 2006-05-22 08:00 A → 2006-05-22 A | 2006-05-23 17:00 A → 2006-05-23 A |  |
| 13 | **Argos transmitter** | 2006-04-24 08:00 A → 2006-04-24 A | 2006-07-04 17:00 A → 2006-07-04 A |  |
| 14 | set up account | 2006-04-24 08:00 A → 2006-04-24 A | 2006-04-25 12:00 A → 2006-04-25 A |  |
| 15 | Design and build a bracket | 2006-07-03 08:00 A → 2006-07-03 A | 2006-07-04 17:00 A → 2006-07-04 A |  |
| 16 | **Spar Buoy** | 2006-04-24 08:00 A → 2006-04-24 A | 2006-06-01 17:00 A → 2006-06-01 A |  |
| 17 | Update model with SIO Spar Buoy components | 2006-04-24 08:00 A → 2006-04-24 A | 2006-04-25 12:00 A → 2006-04-25 A |  |
| 18 | ship components from SIO to MBARI | 2006-05-15 08:00 A → 2006-05-15 A | 2006-05-26 17:00 A → 2006-05-26 A | constraint start no earlier than 2006-05-15 08:00 → start no earlier than 2006-05-15 |
| 19 | Assemble spar buoy assembly | 2006-05-29 08:00 A → 2006-05-29 A | 2006-06-01 17:00 A → 2006-06-01 A |  |
| 20 | confirm Atlantis can receive 159.480 MHz | 2006-04-24 08:00 A → 2006-04-24 A | 2006-04-24 10:00 A → 2006-04-24 A |  |
| 21 | order connector rope | 2006-04-24 08:00 A → 2006-04-24 A | 2006-04-24 12:00 A → 2006-04-24 A |  |
| 22 | **Oil compensator** | 2006-05-01 08:00 A → 2006-05-01 A | 2006-05-26 17:00 A → 2006-05-26 A |  |
| 23 | Fabricate parts | 2006-05-01 08:00 A → 2006-05-01 A | 2006-05-18 17:00 A → 2006-05-18 A | constraint start no earlier than 2006-05-01 08:00 → start no earlier than 2006-05-01 |
| 24 | Build up, fill and test | 2006-05-19 08:00 A → 2006-05-19 A | 2006-05-22 17:00 A → 2006-05-22 A |  |
| 25 | Assemble plumbing | 2006-05-23 08:00 A → 2006-05-23 A | 2006-05-24 17:00 A → 2006-05-24 A |  |
| 26 | Mount on Rover | 2006-05-25 08:00 A → 2006-05-25 A | 2006-05-26 17:00 A → 2006-05-26 A |  |
| 27 | **Shipboard cradle** | 2006-05-29 08:00 A → 2006-05-29 A | 2006-06-09 17:00 A → 2006-06-09 A |  |
| 28 | Design cradle | 2006-05-29 08:00 A → 2006-05-29 A | 2006-05-29 12:00 A → 2006-05-29 A |  |
| 29 | order parts | 2006-05-29 13:00 A → 2006-05-29 A | 2006-05-30 17:00 A → 2006-05-30 A |  |
| 30 | fabricate and install | 2006-05-31 08:00 A → 2006-05-31 A | 2006-06-09 17:00 A → 2006-06-09 A |  |
| 31 | CDR prep | 2006-04-24 08:00 A → 2006-04-24 A | 2006-04-26 12:00 A → 2006-04-26 A |  |
| 32 | **Pressure Housings** | 2006-04-18 08:00 A → 2006-04-18 A | 2006-06-21 12:00 A → 2006-06-21 A |  |
| 33 | **Battery Sphere** | 2006-04-18 08:00 A → 2006-04-18 A | 2006-06-15 17:00 A → 2006-06-15 A |  |
| 34 | Design alkaline battery pack frame | 2006-05-09 13:00 A → 2006-05-09 A | 2006-05-11 12:00 A → 2006-05-11 A |  |
| 35 | Fabricate internal frame and mounts | 2006-06-12 08:00 A → 2006-06-12 A | 2006-06-15 17:00 A → 2006-06-15 A |  |
| 36 | Machine Housing | 2006-04-18 08:00 A → 2006-04-18 A | 2006-05-15 17:00 A → 2006-05-15 A | constraint start no earlier than 2006-04-18 08:00 → start no earlier than 2006-04-18 |
| 37 | QC machine work and assemble | 2006-05-16 08:00 A → 2006-05-16 A | 2006-05-19 17:00 A → 2006-05-19 A | constraint start no earlier than 2006-04-18 08:00 → start no earlier than 2006-04-18 |
| 38 | Helium Leak test | 2006-05-22 08:00 A → 2006-05-22 A | 2006-05-23 17:00 A → 2006-05-23 A |  |
| 39 | Mount on Rover | 2006-05-24 08:00 A → 2006-05-24 A | 2006-05-25 17:00 A → 2006-05-25 A |  |
| 40 | **MVC Sphere** | 2006-04-18 08:00 A → 2006-04-18 A | 2006-06-02 17:00 A → 2006-06-02 A |  |
| 41 | Design internal chassis for MVC | 2006-04-24 08:00 A → 2006-04-24 A | 2006-04-26 12:00 A → 2006-04-26 A |  |
| 42 | Design Seacon plugs | 2006-04-24 08:00 A → 2006-04-24 A | 2006-04-25 12:00 A → 2006-04-25 A |  |
| 43 | Machine plugs | 2006-04-25 13:00 A → 2006-04-25 A | 2006-04-26 12:00 A → 2006-04-26 A |  |
| 44 | Machine Housing | 2006-04-18 08:00 A → 2006-04-18 A | 2006-05-15 17:00 A → 2006-05-15 A | constraint start no earlier than 2006-04-18 08:00 → start no earlier than 2006-04-18 |
| 45 | QC machine work and assemble | 2006-05-22 08:00 A → 2006-05-22 A | 2006-05-25 17:00 A → 2006-05-25 A |  |
| 46 | Helium leak test | 2006-05-26 08:00 A → 2006-05-26 A | 2006-05-29 17:00 A → 2006-05-29 A |  |
| 47 | Mount on Rover | 2006-05-30 08:00 A → 2006-05-30 A | 2006-06-02 17:00 A → 2006-06-02 A |  |
| 48 | **Motor controller** | 2006-04-24 08:00 A → 2006-04-24 A | 2006-06-21 12:00 A → 2006-06-21 A |  |
| 49 | Design motor controller housings | 2006-04-24 08:00 A → 2006-04-24 A | 2006-05-04 12:00 A → 2006-05-04 A |  |
| 50 | Confirm design with FEA | 2006-05-04 13:00 A → 2006-05-04 A | 2006-05-05 12:00 A → 2006-05-05 A |  |
| 51 | Generate machine prints for Ti parts | 2006-05-05 13:00 A → 2006-05-05 A | 2006-05-09 12:00 A → 2006-05-09 A |  |
| 52 | Drawing check | 2006-05-09 13:00 A → 2006-05-09 A | 2006-05-10 12:00 A → 2006-05-10 A |  |
| 53 | Machine parts | 2006-05-10 13:00 A → 2006-05-10 A | 2006-05-31 12:00 A → 2006-05-31 A |  |
| 54 | QC parts and assemble | 2006-05-31 13:00 A → 2006-05-31 A | 2006-06-01 12:00 A → 2006-06-01 A |  |
| 55 | Pressure check | 2006-06-01 13:00 A → 2006-06-01 A | 2006-06-02 12:00 A → 2006-06-02 A |  |
| 56 | Electronics Assembly | 2006-06-02 13:00 A → 2006-06-02 A | 2006-06-05 12:00 A → 2006-06-05 A |  |
| 57 | Final assembly, He leak test | 2006-06-05 13:00 A → 2006-06-05 A | 2006-06-09 12:00 A → 2006-06-09 A |  |
| 58 | Mount on Rover | 2006-06-09 13:00 A → 2006-06-09 A | 2006-06-15 12:00 A → 2006-06-15 A |  |
| 59 | Design Ti sphere mounting brackets | 2006-04-24 08:00 A → 2006-04-24 A | 2006-04-28 12:00 A → 2006-04-28 A |  |
| 60 | **Motion monitoring data logger** | 2006-05-09 13:00 A → 2006-05-09 A | 2006-05-18 12:00 A → 2006-05-18 A |  |
| 61 | Confirm specs with Andy | 2006-05-09 13:00 A → 2006-05-09 A | 2006-05-11 12:00 A → 2006-05-11 A |  |
| 62 | Program and build up system | 2006-05-11 13:00 A → 2006-05-11 A | 2006-05-12 12:00 A → 2006-05-12 A |  |
| 63 | Mount to Rover | 2006-05-12 13:00 A → 2006-05-12 A | 2006-05-18 12:00 A → 2006-05-18 A |  |
| 64 | **Homer transponder** | 2006-04-24 08:00 A → 2006-04-24 A | 2006-06-21 12:00 A → 2006-06-21 A |  |
| 65 | Check out deep homer from DMO | 2006-04-24 08:00 A → 2006-04-24 A | 2006-04-25 12:00 A → 2006-04-25 A |  |
| 66 | Fabricate bracket and mount Homer | 2006-06-15 13:00 A → 2006-06-15 A | 2006-06-21 12:00 A → 2006-06-21 A |  |
| 67 | Design lifting sling/eye | 2006-06-21 13:00 A → 2006-06-21 A | 2006-06-27 12:00 A → 2006-06-27 A |  |
| 68 | Remount floatation blocks | 2006-06-27 13:00 A → 2006-06-27 A | 2006-06-29 12:00 A → 2006-06-29 A |  |
| 69 | Design brackets for A-modem | 2006-06-29 13:00 A → 2006-06-29 A | 2006-06-29 17:00 A → 2006-06-29 A |  |
| 70 | Design brackets for current meter | 2006-06-30 08:00 A → 2006-06-30 A | 2006-06-30 17:00 A → 2006-06-30 A |  |

| ID | Task | Start | Finish | Duration | Complete | Total float | Predecessors | Other |
| --- | --- | --- | --- | --- | --- | --- | --- | --- |
| 71 | Mount Football Floats | 2006-07-03 08:00 A → 2006-07-03 A | 2006-07-06 17:00 A → 2006-07-06 A |  |  |  |  |  |
| 72 | Measure wet weight | 2006-07-07 08:00 A → 2006-07-07 A | 2006-07-07 17:00 A → 2006-07-07 A |  |  |  |  |  |
| 73 | Update trim and balance | 2006-07-10 08:00 A → 2006-07-10 A | 2006-07-10 17:00 A → 2006-07-10 A |  |  |  |  |  |
| 74 | Design and order lead ballast | 2006-07-11 08:00 A → 2006-07-11 A | 2006-07-11 17:00 A → 2006-07-11 A |  |  |  |  |  |
| 75 | **Testing** | 2006-06-05 08:00 A → 2006-06-05 A | 2006-07-21 08:00 A → 2006-07-21 A |  |  |  |  |  |
| 76 | Lab Tests | 2006-06-05 08:00 A → 2006-06-05 A | 2006-06-06 17:00 A → 2006-06-06 A |  |  |  |  | constraint start no earlier than 2006-06-05 08:00 → start no earlier than 2006-06-05 |
| 77 | Tank Testing | 2006-07-12 08:00 A → 2006-07-12 A | 2006-07-12 17:00 A → 2006-07-12 A |  |  |  |  | constraint start no earlier than 2006-06-07 08:00 → start no earlier than 2006-06-07 |
| 78 | Ready for Sea Tests | 2006-07-12 17:00 A → 2006-07-12 A | 2006-07-12 17:00 A → 2006-07-12 A |  |  |  |  |  |
| 79 | Pt. Lobos | 2006-07-13 08:00 A → 2006-07-13 A | 2006-07-18 17:00 A → 2006-07-18 A |  |  |  |  | constraint finish no earlier than 2006-06-19 17:00 → finish no earlier than 2006-06-19 |
| 80 | Upgrades/Rework | 2006-07-19 08:00 A → 2006-07-19 A | 2006-07-19 17:00 A → 2006-07-19 A |  |  |  |  |  |
| 81 | Final pool test | 2006-07-20 08:00 A → 2006-07-20 A | 2006-07-20 17:00 A → 2006-07-20 A |  |  |  |  |  |
| 82 | Ready for shipment | 2006-07-21 08:00 A → 2006-07-21 A | 2006-07-21 08:00 A → 2006-07-21 A |  |  |  |  | constraint start no earlier than 2006-07-21 08:00 → start no earlier than 2006-07-21 |
| 83 | Atlantis Cruise | 2006-08-08 08:00 A → 2006-08-08 A | 2006-09-07 17:00 A → 2006-09-07 A |  |  |  |  | constraint start no earlier than 2006-08-08 08:00 → start no earlier than 2006-08-08 |
| 84 | **Flyer Cruise Tasks** | 2006-04-24 08:00 A → 2006-04-24 A | 2006-12-04 12:00 → 2006-12-04 |  | 14% → 44% |  |  |  |
| 85 | **Design** | 2006-10-02 08:00 A → 2006-10-02 A | 2006-10-30 17:00 → 2006-10-30 |  | 71% → 96% |  |  |  |
| 86 | Design Racks | 2006-10-02 08:00 A → 2006-10-02 A | 2006-10-18 17:00 A → 2006-10-18 A |  |  |  |  | constraint finish no earlier than 2006-10-18 17:00 → finish no earlier than 2006-10-18 |
| 87 | Design Respirometers | 2006-10-03 08:00 A → 2006-10-03 A | 2006-10-27 17:00 → 2006-10-27 |  | 40% → 90% | 25.1d → 25.5d |  | constraint finish no earlier than 2006-10-18 17:00 → finish no earlier than 2006-10-18 |
| 88 | Clean up Rover Drawings | 2006-10-04 08:00 A → 2006-10-04 A | 2006-10-30 17:00 → 2006-10-30 A |  | 80% → 100% | 24.5d → none |  | constraint finish no earlier than 2006-10-18 17:00 → finish no earlier than 2006-10-18 |
| 89 | CDR | 2006-10-12 08:00 A → 2006-10-12 A | 2006-10-18 17:00 → 2006-10-18 A |  | 3% → 100% | 1.65d → none |  |  |
| 90 | **Complete Drawing package for shop** | 2006-10-19 08:00 A → 2006-10-19 A | 2006-10-24 14:36 → 2006-10-24 |  |  |  |  |  |
| 91 | **Rack drawings** | 2006-10-19 08:00 → 2006-10-19 | 2006-10-20 17:00 → 2006-10-20 |  |  |  |  |  |
| 92 | Frame | 2006-10-19 08:00 → 2006-10-19 | 2006-10-19 12:00 → 2006-10-19 |  |  |  |  |  |
| 93 | I-beam blocks | 2006-10-19 13:00 → 2006-10-19 | 2006-10-19 17:00 → 2006-10-19 |  |  |  |  |  |
| 94 | **Motor assembly** | 2006-10-19 08:00 → 2006-10-19 | 2006-10-19 17:00 → 2006-10-19 |  |  |  |  |  |
| 95 | finish output shaft | 2006-10-19 08:00 → 2006-10-19 | 2006-10-19 12:00 → 2006-10-19 |  |  |  |  |  |
| 96 | other | 2006-10-19 13:00 → 2006-10-19 | 2006-10-19 17:00 → 2006-10-19 |  |  |  |  |  |
| 97 | **Leadscrew assembly** | 2006-10-20 08:00 → 2006-10-20 | 2006-10-20 17:00 → 2006-10-20 |  |  |  |  |  |
| 98 | Leadscrew mods | 2006-10-20 08:00 → 2006-10-20 | 2006-10-20 12:00 → 2006-10-20 |  |  |  |  |  |
| 99 | bearing support details | 2006-10-20 13:00 → 2006-10-20 | 2006-10-20 17:00 → 2006-10-20 |  |  |  |  |  |
| 100 | Cart | 2006-10-20 08:00 → 2006-10-20 | 2006-10-20 12:00 → 2006-10-20 |  |  |  |  |  |
| 101 | **respirometer drawings** | 2006-10-19 08:00 A → 2006-10-19 A | 2006-10-24 14:36 → 2006-10-24 |  |  |  |  |  |
| 102 | chambers | 2006-10-19 08:00 → 2006-10-19 | 2006-10-19 12:00 → 2006-10-19 |  |  |  |  |  |
| 103 | optode | 2006-10-19 13:00 → 2006-10-19 | 2006-10-19 14:36 → 2006-10-19 |  |  |  |  |  |
| 104 | vents | 2006-10-19 14:36 → 2006-10-19 | 2006-10-20 14:36 → 2006-10-20 |  |  |  |  |  |
| 105 | stirer | 2006-10-20 14:36 → 2006-10-20 | 2006-10-23 14:36 → 2006-10-23 |  |  |  |  |  |
| 106 | j-box | 2006-10-24 09:36 A → 2006-10-24 A | 2006-10-24 14:36 A → 2006-10-24 A |  |  |  |  |  |
| 107 | touchdown switch | 2006-10-19 08:00 → 2006-10-19 | 2006-10-19 12:00 → 2006-10-19 |  |  |  |  |  |
| 108 | chamber knife | 2006-10-19 13:00 → 2006-10-19 | 2006-10-20 12:00 → 2006-10-20 |  |  |  |  |  |
| 109 | Pump, plumbing and manifold | 2006-10-20 13:00 → 2006-10-20 | 2006-10-23 12:00 → 2006-10-23 |  |  |  |  |  |
| 110 | Machine parts | 2006-10-20 08:00 → 2006-10-20 | 2006-11-16 17:00 → 2006-11-16 |  |  |  |  |  |
| 111 | Order materials | 2006-10-20 13:00 → 2006-10-20 A | 2006-10-23 12:00 → 2006-10-23 |  | 0% → 80% |  |  |  |
| 112 | Order U/W connectors | 2006-10-20 08:00 → 2006-10-20 A | 2006-11-16 17:00 → 2006-11-16 A |  | 0% → 100% | 2.65d → none |  | constraint start no earlier than 2006-10-20 08:00 → start no earlier than 2006-10-20 |
| 113 | **Rack Assembly** | 2006-04-24 08:00 → 2006-04-24 A | 2006-11-22 09:36 → 2006-11-22 |  | 0% → 1% |  | 118 → none |  |
| 114 | **Fab Frame** | 2006-04-24 08:00 → 2006-04-24 A | 2006-10-24 12:00 → 2006-10-24 |  | 0% → 8% |  |  |  |
| 115 | Fab rack mount blocks | 2006-10-23 13:00 → 2006-10-23 | 2006-10-24 12:00 → 2006-10-24 |  |  |  |  |  |
| 116 | Cut I-beams | 2006-04-24 08:00 → 2006-04-24 A | 2006-04-24 11:12 → 2006-04-24 |  | 0% → 50% |  |  |  |
| 117 | mount blocks | 2006-04-24 11:12 → 2006-04-24 | 2006-04-25 08:48 → 2006-04-25 |  |  |  |  |  |
| 118 | fab tube mounts | 2006-04-25 08:48 → 2006-04-25 | 2006-04-25 13:48 → 2006-04-25 |  |  |  |  |  |
| 119 | square up and assemble frame | 2006-04-25 13:48 → 2006-04-25 | 2006-04-25 17:00 → 2006-04-25 |  |  |  |  |  |
| 120 | **Cart** | 2006-04-26 08:00 → 2006-04-26 | 2006-11-17 17:00 → 2006-11-17 |  |  |  |  |  |
| 121 | Cut and clean up shafts | 2006-04-26 08:00 → 2006-04-26 | 2006-04-26 09:36 → 2006-04-26 |  |  |  |  |  |
| 122 | fab wheels | 2006-04-26 09:36 → 2006-04-26 | 2006-04-26 14:36 → 2006-04-26 |  |  |  |  |  |
| 123 | fab and mount sliders | 2006-04-26 14:36 → 2006-04-26 | 2006-04-26 16:12 → 2006-04-26 |  |  |  |  |  |
| 124 | assemble cart | 2006-11-17 08:00 → 2006-11-17 | 2006-11-17 17:00 → 2006-11-17 |  |  |  |  |  |
| 125 | **Motor Assembly** | 2006-04-24 08:00 → 2006-04-24 | 2006-11-20 14:36 → 2006-11-20 |  |  |  |  |  |
| 126 | prep motors for oil | 2006-10-23 08:00 → 2006-10-23 | 2006-10-23 12:00 → 2006-10-23 |  |  |  |  |  |
| 127 | wireup and build motor assembly | 2006-11-17 08:00 → 2006-11-17 | 2006-11-17 12:00 → 2006-11-17 |  |  |  |  |  |
| 128 | add inserts and standoffs to amp endcap | 2006-11-17 13:00 → 2006-11-17 | 2006-11-17 14:36 → 2006-11-17 |  |  |  |  |  |
| 129 | install and wireup ez-servo | 2006-11-17 14:36 → 2006-11-17 | 2006-11-20 09:36 → 2006-11-20 |  |  |  |  |  |
| 130 | assemble comp plumbing to motor block | 2006-11-20 09:36 → 2006-11-20 | 2006-11-20 14:36 → 2006-11-20 |  |  |  |  | resources John → Jim |
| 131 | Modify leadscrew | 2006-04-24 08:00 → 2006-04-24 | 2006-04-25 12:00 → 2006-04-25 |  |  |  |  |  |
| 132 | assemble leadscrew | 2006-04-24 08:00 → 2006-04-24 | 2006-04-25 12:00 → 2006-04-25 |  |  |  |  |  |
| 133 | Rack assembly | 2006-11-20 14:36 → 2006-11-20 | 2006-11-21 14:36 → 2006-11-21 |  |  |  |  |  |
| 134 | Final assembly | 2006-11-21 14:36 → 2006-11-21 | 2006-11-22 09:36 → 2006-11-22 |  |  |  |  |  |
| 135 | **Touchdown switch** | 2006-10-27 10:24 → 2006-04-24 (-186d) | 2006-10-27 14:36 → 2006-04-27 (-183d) | 0.4d? → 4d? |  | 22.7d → 156.5d |  |  |
| 137 | Assemble and test plunger | 2006-10-27 13:00 → 2006-04-25 (-185d) | 2006-10-27 14:36 → 2006-04-26 (-184d) | 0.2d? → 1d? |  | 22.7d → 158d | Assemble and glue body → 136 |  |
| 138 | **Vents** | 2006-10-24 16:12 → 2006-04-24 (-183d) | 2006-10-27 10:24 → 2006-04-27 (-183d) | 2.4d? → 4d? |  | 20.55d → 156.5d |  |  |
| 140 | fill with oil and test | 2006-10-25 16:12 → 2006-04-26 (-182d) | 2006-10-26 08:48 → 2006-04-26 (-183d) | 0.2d? → 0.5d? |  | 20.55d → 157.5d | assemble parts → 139 | resources John → Jim |
| 141 | cold room test | 2006-10-26 08:48 → 2006-04-26 (-183d) | 2006-10-26 10:24 → 2006-04-26 (-183d) | 0.2d? → 0.5d? |  | 20.55d → 157.5d |  | resources John → Jim |
| 142 | **Hall effect switches (3)** | 2006-10-19 08:00 → 2006-04-24 (-178d) | 2006-10-20 17:00 → 2006-04-27 (-176d) | 2d? → 4d? |  | 30.5d → 156.5d |  |  |

| ID | Task | Start | Finish | Duration | Total float | Predecessors | Other |
| --- | --- | --- | --- | --- | --- | --- | --- |
| 143 | mold switches | 2006-10-19 08:00 → 2006-04-24 (-178d) | 2006-10-19 17:00 → 2006-04-26 (-176d) | 1d? → 3d? | 30.5d → 156.5d | 89 → none |  |
| 144 | assemble wiring and plumbing | 2006-10-20 08:00 → 2006-04-27 (-176d) | 2006-10-20 17:00 → 2006-04-27 (-176d) |  | 30.5d → 156.5d |  |  |
| 145 | **Other Tasks** | 2006-10-11 08:00 A → 2006-10-11 A | 2006-12-04 12:00 → 2006-12-04 |  |  |  |  |
| 146 | Re-assemble Strb drive motor and both amps | 2006-11-16 09:36 A → 2006-11-16 A | 2006-11-17 09:36 → 2006-11-17 |  |  | Build 5 more units → none |  |
| 147 | Modify drop weight jack | 2006-10-11 08:00 A → 2006-10-11 A | 2006-10-11 17:00 → 2006-10-11 |  |  |  |  |
| 148 | Re-load drop weight | 2006-10-12 08:00 → 2006-10-12 | 2006-10-12 09:36 → 2006-10-12 |  |  |  |  |
| 149 | Buy, mount and wireup camera(s) | 2006-10-12 09:36 → 2006-10-12 | 2006-10-13 09:36 → 2006-10-13 |  |  |  |  |
| 150 | Assemble and test acoustic modem | 2006-12-04 08:00 → 2006-12-04 | 2006-12-04 12:00 → 2006-12-04 |  |  |  |  |
| 151 | Assembe two more oil compensators, mount, fill and bleed | 2006-11-17 09:36 → 2006-11-17 | 2006-11-17 14:36 → 2006-11-17 |  |  |  |  |
| 152 | Tank tests | 2006-11-22 15:48 → 2006-11-17 (-5d) | 2006-11-27 15:48 → 2006-11-22 (-5d) |  | 2.65d → 5.8d | Mount on Rover, 151 → 151 |  |
| 153 | Rework | 2006-11-27 15:48 → 2006-11-22 (-5d) | 2006-11-28 15:48 → 2006-11-23 (-5d) |  | 2.65d → 5.8d |  |  |
| 154 | Retest in tank | 2006-11-28 15:48 → 2006-11-23 (-5d) | 2006-11-29 15:48 → 2006-11-24 (-5d) |  | 2.65d → 5.8d |  |  |
| 155 | Pt. Lobos Cruise | 2006-12-04 08:00 → 2006-12-04 | 2006-12-04 12:00 → 2006-12-04 |  |  |  | constraint start no earlier than 2006-12-04 08:00 → start no earlier than 2006-12-04 |
